# BB-07 - met staalskelet

Schedule from MS Project, 2003-01-08 to 2003-01-17, status date 2003-01-08.
BAM Nelissen Van Egteren

## Calendars

- ALLEEN WERKDAGEN: Mon-Fri 08:30-12:30, 13:00-17:00; Sat-Sun off. Exceptions (off unless hours are given): 2003-01-11 to 2003-01-12 08:30-12:30, 13:00-17:00.

## Schedule

| ID | WBS | Task | Type | Duration | Start | Finish | Predecessors | Total slack |
| --- | --- | --- | --- | --- | --- | --- | --- | --- |
| 1 | 1 | **BOVENBOUWFASE** |  | 10d | 2003-01-08 | 2003-01-17 |  | 0d |
| 2 | 1.1 | ankerbouten controleren |  | 1d | 2003-01-08 | 2003-01-08 |  | 0d |
| 3 | 1.2 | stalen kolommen stellen |  | 2d | 2003-01-09 | 2003-01-10 | 2SS+1d | 0d |
| 4 | 1.3 | stalen hoofdliggers monteren |  | 2d | 2003-01-11 | 2003-01-12 | 3SS+2d | 0d |
| 5 | 1.4 | skelet uitrichten+afstellen |  | 2d | 2003-01-13 | 2003-01-14 | 4SS+2d | 0d |
| 6 | 1.5 | stalen dakgordingen monteren |  | 2d | 2003-01-15 | 2003-01-16 | 5SS+2d | 0d |
| 7 | 1.6 | windverband aanbrengen |  | 1d | 2003-01-17 | 2003-01-17 | 6SS+2d | 0d |
| 8 | 1.7 | start geve/dak fase | milestone | 0d | 2003-01-17 | 2003-01-17 | 7SS+1d | 0d |
